/*
 * This file has been generated by TaskJuggler 2.4.3
 * at 2010-09-06 20:03:20 CDT.
 */
/*
 * For details about TaskJuggler see http://www.taskjuggler.org
 */
project accounting "Accounting Software" "1.0" 2010-09-06-00:00:00--0500 - 2011-06-13-00:00:00--0500 {
  dailyworkinghours 8
  yearlyworkingdays 260.714
  timingresolution 60min
  now 2010-09-06-20:00:00--0500
  timeformat "%Y-%m-%d %H:%M"
  shorttimeformat "%H:%M"
  currencyformat "(" ")" "," "." 0
  weekstartsmonday
  workinghours sun off
  workinghours mon 9:00 - 12:00, 13:00 - 18:00
  workinghours tue 9:00 - 12:00, 13:00 - 18:00
  workinghours wed 9:00 - 12:00, 13:00 - 18:00
  workinghours thu 9:00 - 12:00, 13:00 - 18:00
  workinghours fri 9:00 - 12:00, 13:00 - 18:00
  workinghours sat off
  scenario plan "Plan" {
    enabled
  }
}
shift s40 "Part time shift" {
  workinghours wed off
  workinghours thu off
  workinghours fri off
}
resource resources "Resources" {
  resource dev "Developers" {
    resource paul "Paul Smith" {
    }
    resource seb "Sébastien Bono" {
    }
    resource klaus "Klaus Müller" {
    }
  }
  resource others "Others" {
    resource doc "Peter Murphy" {
    }
    resource test "Dim Sung" {
    }
  }
}
projectids accounting
task accounting "Accounting Software" {
  projectid accounting
  task specification "Specification" {
    depends accounting.milestones.project
    plan:start 2010-09-06-09:00:00--0500
    plan:end 2010-09-14-16:00:00--0500
    plan:scheduled
    scheduling asap
  }
  task software "Software Development" {
    depends accounting.specification
    task database "Database coupling" {
      plan:start 2010-09-14-16:00:00--0500
      plan:end 2010-09-23-14:00:00--0500
      plan:scheduled
      scheduling asap
    }
    task back_end "Back-End Functions" {
      depends accounting.software.database
      plan:start 2010-09-23-14:00:00--0500
      plan:end 2010-10-07-14:00:00--0500
      plan:scheduled
      scheduling asap
    }
    task graphical "Graphical User Interface" {
      depends accounting.software.back_end
      plan:start 2010-10-07-14:00:00--0500
      plan:end 2010-11-01-18:00:00--0500
      plan:scheduled
      scheduling asap
    }
    scheduling asap
  }
  task software_testing "Software testing" {
    depends accounting.software
    task alpha "Alpha Test" {
      plan:start 2010-11-02-09:00:00--0500
      plan:end 2010-11-08-18:00:00--0600
      plan:scheduled
      scheduling asap
    }
    task beta "Beta Test" {
      depends accounting.software_testing.alpha
      plan:start 2010-11-09-09:00:00--0600
      plan:end 2010-11-22-18:00:00--0600
      plan:scheduled
      scheduling asap
    }
    scheduling asap
  }
  task manual "Manual" {
    depends accounting.milestones.project
    plan:start 2010-09-06-09:00:00--0500
    plan:end 2010-12-07-14:00:00--0600
    plan:scheduled
    scheduling asap
  }
  task milestones "Milestones" {
    task project "Project start" {
      start 2010-09-06
      end 2010-09-06
      plan:scheduled
      milestone 
      scheduling asap
    }
    task technology "Technology Preview" {
      depends accounting.software.back_end
      start 2010-10-08
      end 2010-10-08
      plan:scheduled
      milestone 
      scheduling asap
    }
    task beta "Beta version" {
      depends accounting.software_testing.alpha
      start 2010-11-09
      end 2010-11-09
      plan:scheduled
      milestone 
      scheduling asap
    }
    task ship "Ship Product to Customer" {
      depends accounting.software_testing.beta, accounting.manual
      start 2010-12-08
      end 2010-12-08
      plan:scheduled
      milestone 
      scheduling asap
    }
    scheduling asap
  }
  scheduling asap
}
supplement task accounting {
  supplement task specification {
  }
  supplement task software {
    supplement task database {
    }
    supplement task back_end {
    }
    supplement task graphical {
    }
  }
  supplement task software_testing {
    supplement task alpha {
    }
    supplement task beta {
    }
  }
  supplement task manual {
  }
  supplement task milestones {
    supplement task project {
    }
    supplement task technology {
    }
    supplement task beta {
    }
    supplement task ship {
    }
  }
  priority 500
}
supplement resource klaus {
  plan:booking accounting.specification
    2010-09-06-09:00:00--0500 +3h,
    2010-09-06-13:00:00--0500 +5h,
    2010-09-07-09:00:00--0500 +3h,
    2010-09-07-13:00:00--0500 +5h,
    2010-09-08-09:00:00--0500 +3h,
    2010-09-08-13:00:00--0500 +5h,
    2010-09-09-09:00:00--0500 +3h,
    2010-09-09-13:00:00--0500 +5h,
    2010-09-10-09:00:00--0500 +3h,
    2010-09-10-13:00:00--0500 +5h,
    2010-09-13-09:00:00--0500 +3h,
    2010-09-13-13:00:00--0500 +5h,
    2010-09-14-09:00:00--0500 +3h,
    2010-09-14-13:00:00--0500 +3h { overtime 2 }
  plan:booking accounting.software.database
    2010-09-14-16:00:00--0500 +2h,
    2010-09-15-09:00:00--0500 +3h,
    2010-09-15-13:00:00--0500 +5h,
    2010-09-16-09:00:00--0500 +3h,
    2010-09-16-13:00:00--0500 +5h,
    2010-09-17-09:00:00--0500 +3h,
    2010-09-17-13:00:00--0500 +5h,
    2010-09-20-09:00:00--0500 +3h,
    2010-09-20-13:00:00--0500 +5h,
    2010-09-21-09:00:00--0500 +3h,
    2010-09-21-13:00:00--0500 +5h,
    2010-09-22-09:00:00--0500 +3h,
    2010-09-22-13:00:00--0500 +5h,
    2010-09-23-09:00:00--0500 +3h,
    2010-09-23-13:00:00--0500 +1h { overtime 2 }
  plan:booking accounting.software.back_end
    2010-09-23-14:00:00--0500 +4h,
    2010-09-24-09:00:00--0500 +3h,
    2010-09-24-13:00:00--0500 +5h,
    2010-09-27-09:00:00--0500 +3h,
    2010-09-27-13:00:00--0500 +5h,
    2010-09-28-09:00:00--0500 +3h,
    2010-09-28-13:00:00--0500 +5h,
    2010-09-29-09:00:00--0500 +3h,
    2010-09-29-13:00:00--0500 +5h,
    2010-09-30-09:00:00--0500 +3h,
    2010-09-30-13:00:00--0500 +5h,
    2010-10-01-09:00:00--0500 +3h,
    2010-10-01-13:00:00--0500 +5h,
    2010-10-04-09:00:00--0500 +3h,
    2010-10-04-13:00:00--0500 +5h,
    2010-10-05-09:00:00--0500 +3h,
    2010-10-05-13:00:00--0500 +5h,
    2010-10-06-09:00:00--0500 +3h,
    2010-10-06-13:00:00--0500 +5h,
    2010-10-07-09:00:00--0500 +3h,
    2010-10-07-13:00:00--0500 +1h
}
supplement resource paul {
  plan:booking accounting.specification
    2010-09-06-09:00:00--0500 +3h,
    2010-09-06-13:00:00--0500 +5h,
    2010-09-07-09:00:00--0500 +3h,
    2010-09-07-13:00:00--0500 +5h,
    2010-09-08-09:00:00--0500 +3h,
    2010-09-08-13:00:00--0500 +5h,
    2010-09-09-09:00:00--0500 +3h,
    2010-09-09-13:00:00--0500 +5h,
    2010-09-10-09:00:00--0500 +3h,
    2010-09-10-13:00:00--0500 +5h,
    2010-09-13-09:00:00--0500 +3h,
    2010-09-13-13:00:00--0500 +5h,
    2010-09-14-09:00:00--0500 +3h,
    2010-09-14-13:00:00--0500 +3h { overtime 2 }
  plan:booking accounting.software.database
    2010-09-14-16:00:00--0500 +2h,
    2010-09-15-09:00:00--0500 +3h,
    2010-09-15-13:00:00--0500 +5h,
    2010-09-16-09:00:00--0500 +3h,
    2010-09-16-13:00:00--0500 +5h,
    2010-09-17-09:00:00--0500 +3h,
    2010-09-17-13:00:00--0500 +5h,
    2010-09-20-09:00:00--0500 +3h,
    2010-09-20-13:00:00--0500 +5h,
    2010-09-21-09:00:00--0500 +3h,
    2010-09-21-13:00:00--0500 +5h,
    2010-09-22-09:00:00--0500 +3h,
    2010-09-22-13:00:00--0500 +5h,
    2010-09-23-09:00:00--0500 +3h,
    2010-09-23-13:00:00--0500 +1h { overtime 2 }
  plan:booking accounting.software.back_end
    2010-09-23-14:00:00--0500 +4h,
    2010-09-24-09:00:00--0500 +3h,
    2010-09-24-13:00:00--0500 +5h,
    2010-09-27-09:00:00--0500 +3h,
    2010-09-27-13:00:00--0500 +5h,
    2010-09-28-09:00:00--0500 +3h,
    2010-09-28-13:00:00--0500 +5h,
    2010-09-29-09:00:00--0500 +3h,
    2010-09-29-13:00:00--0500 +5h,
    2010-09-30-09:00:00--0500 +3h,
    2010-09-30-13:00:00--0500 +5h,
    2010-10-01-09:00:00--0500 +3h,
    2010-10-01-13:00:00--0500 +5h,
    2010-10-04-09:00:00--0500 +3h,
    2010-10-04-13:00:00--0500 +5h,
    2010-10-05-09:00:00--0500 +3h,
    2010-10-05-13:00:00--0500 +5h,
    2010-10-06-09:00:00--0500 +3h,
    2010-10-06-13:00:00--0500 +5h,
    2010-10-07-09:00:00--0500 +3h,
    2010-10-07-13:00:00--0500 +1h { overtime 2 }
  plan:booking accounting.software.graphical
    2010-10-07-14:00:00--0500 +4h,
    2010-10-08-09:00:00--0500 +3h,
    2010-10-08-13:00:00--0500 +5h,
    2010-10-11-09:00:00--0500 +3h,
    2010-10-11-13:00:00--0500 +5h,
    2010-10-12-09:00:00--0500 +3h,
    2010-10-12-13:00:00--0500 +5h,
    2010-10-13-09:00:00--0500 +3h,
    2010-10-13-13:00:00--0500 +5h,
    2010-10-14-09:00:00--0500 +3h,
    2010-10-14-13:00:00--0500 +5h,
    2010-10-15-09:00:00--0500 +3h,
    2010-10-15-13:00:00--0500 +5h,
    2010-10-18-09:00:00--0500 +3h,
    2010-10-18-13:00:00--0500 +5h,
    2010-10-19-09:00:00--0500 +3h,
    2010-10-19-13:00:00--0500 +5h,
    2010-10-20-09:00:00--0500 +3h,
    2010-10-20-13:00:00--0500 +5h,
    2010-10-21-09:00:00--0500 +3h,
    2010-10-21-13:00:00--0500 +5h,
    2010-10-22-09:00:00--0500 +3h,
    2010-10-22-13:00:00--0500 +5h,
    2010-10-25-09:00:00--0500 +3h,
    2010-10-25-13:00:00--0500 +5h,
    2010-10-26-09:00:00--0500 +3h,
    2010-10-26-13:00:00--0500 +5h,
    2010-10-27-09:00:00--0500 +3h,
    2010-10-27-13:00:00--0500 +5h,
    2010-10-28-09:00:00--0500 +3h,
    2010-10-28-13:00:00--0500 +5h,
    2010-10-29-09:00:00--0500 +3h,
    2010-10-29-13:00:00--0500 +5h,
    2010-11-01-09:00:00--0500 +3h,
    2010-11-01-13:00:00--0500 +5h { overtime 2 }
  plan:booking accounting.software_testing.beta
    2010-11-09-09:00:00--0600 +3h,
    2010-11-09-13:00:00--0600 +5h,
    2010-11-10-09:00:00--0600 +3h,
    2010-11-10-13:00:00--0600 +5h,
    2010-11-11-09:00:00--0600 +3h,
    2010-11-11-13:00:00--0600 +5h,
    2010-11-12-09:00:00--0600 +3h,
    2010-11-12-13:00:00--0600 +5h,
    2010-11-15-09:00:00--0600 +3h,
    2010-11-15-13:00:00--0600 +5h,
    2010-11-16-09:00:00--0600 +3h,
    2010-11-16-13:00:00--0600 +5h,
    2010-11-17-09:00:00--0600 +3h,
    2010-11-17-13:00:00--0600 +5h,
    2010-11-18-09:00:00--0600 +3h,
    2010-11-18-13:00:00--0600 +5h,
    2010-11-19-09:00:00--0600 +3h,
    2010-11-19-13:00:00--0600 +5h,
    2010-11-22-09:00:00--0600 +3h,
    2010-11-22-13:00:00--0600 +5h
}
supplement resource seb {
  plan:booking accounting.specification
    2010-09-06-09:00:00--0500 +3h,
    2010-09-06-13:00:00--0500 +5h,
    2010-09-07-09:00:00--0500 +3h,
    2010-09-07-13:00:00--0500 +5h,
    2010-09-08-09:00:00--0500 +3h,
    2010-09-08-13:00:00--0500 +5h,
    2010-09-09-09:00:00--0500 +3h,
    2010-09-09-13:00:00--0500 +5h,
    2010-09-10-09:00:00--0500 +3h,
    2010-09-10-13:00:00--0500 +5h,
    2010-09-13-09:00:00--0500 +3h,
    2010-09-13-13:00:00--0500 +5h,
    2010-09-14-09:00:00--0500 +3h,
    2010-09-14-13:00:00--0500 +3h { overtime 2 }
  plan:booking accounting.software.database
    2010-09-14-16:00:00--0500 +2h,
    2010-09-15-09:00:00--0500 +3h,
    2010-09-15-13:00:00--0500 +5h,
    2010-09-16-09:00:00--0500 +3h,
    2010-09-16-13:00:00--0500 +5h,
    2010-09-17-09:00:00--0500 +3h,
    2010-09-17-13:00:00--0500 +5h,
    2010-09-20-09:00:00--0500 +3h,
    2010-09-20-13:00:00--0500 +5h,
    2010-09-21-09:00:00--0500 +3h,
    2010-09-21-13:00:00--0500 +5h,
    2010-09-22-09:00:00--0500 +3h,
    2010-09-22-13:00:00--0500 +5h,
    2010-09-23-09:00:00--0500 +3h,
    2010-09-23-13:00:00--0500 +1h { overtime 2 }
  plan:booking accounting.software.back_end
    2010-09-23-14:00:00--0500 +4h,
    2010-09-24-09:00:00--0500 +3h,
    2010-09-24-13:00:00--0500 +5h,
    2010-09-27-09:00:00--0500 +3h,
    2010-09-27-13:00:00--0500 +5h,
    2010-09-28-09:00:00--0500 +3h,
    2010-09-28-13:00:00--0500 +5h,
    2010-09-29-09:00:00--0500 +3h,
    2010-09-29-13:00:00--0500 +5h,
    2010-09-30-09:00:00--0500 +3h,
    2010-09-30-13:00:00--0500 +5h,
    2010-10-01-09:00:00--0500 +3h,
    2010-10-01-13:00:00--0500 +5h,
    2010-10-04-09:00:00--0500 +3h,
    2010-10-04-13:00:00--0500 +5h,
    2010-10-05-09:00:00--0500 +3h,
    2010-10-05-13:00:00--0500 +5h,
    2010-10-06-09:00:00--0500 +3h,
    2010-10-06-13:00:00--0500 +5h,
    2010-10-07-09:00:00--0500 +3h,
    2010-10-07-13:00:00--0500 +1h { overtime 2 }
  plan:booking accounting.software.graphical
    2010-10-07-14:00:00--0500 +4h,
    2010-10-08-09:00:00--0500 +3h,
    2010-10-08-13:00:00--0500 +5h,
    2010-10-11-09:00:00--0500 +3h,
    2010-10-11-13:00:00--0500 +5h,
    2010-10-12-09:00:00--0500 +3h,
    2010-10-12-13:00:00--0500 +5h,
    2010-10-13-09:00:00--0500 +3h,
    2010-10-13-13:00:00--0500 +5h,
    2010-10-14-09:00:00--0500 +3h,
    2010-10-14-13:00:00--0500 +5h,
    2010-10-15-09:00:00--0500 +3h,
    2010-10-15-13:00:00--0500 +5h,
    2010-10-18-09:00:00--0500 +3h,
    2010-10-18-13:00:00--0500 +5h,
    2010-10-19-09:00:00--0500 +3h,
    2010-10-19-13:00:00--0500 +5h,
    2010-10-20-09:00:00--0500 +3h,
    2010-10-20-13:00:00--0500 +5h,
    2010-10-21-09:00:00--0500 +3h,
    2010-10-21-13:00:00--0500 +5h,
    2010-10-22-09:00:00--0500 +3h,
    2010-10-22-13:00:00--0500 +5h,
    2010-10-25-09:00:00--0500 +3h,
    2010-10-25-13:00:00--0500 +5h,
    2010-10-26-09:00:00--0500 +3h,
    2010-10-26-13:00:00--0500 +5h,
    2010-10-27-09:00:00--0500 +3h,
    2010-10-27-13:00:00--0500 +5h,
    2010-10-28-09:00:00--0500 +3h,
    2010-10-28-13:00:00--0500 +5h,
    2010-10-29-09:00:00--0500 +3h,
    2010-10-29-13:00:00--0500 +5h,
    2010-11-01-09:00:00--0500 +3h,
    2010-11-01-13:00:00--0500 +5h
}
supplement resource doc {
  plan:booking accounting.manual
    2010-09-06-09:00:00--0500 +3h,
    2010-09-06-13:00:00--0500 +3h,
    2010-09-07-09:00:00--0500 +3h,
    2010-09-07-13:00:00--0500 +3h,
    2010-09-08-09:00:00--0500 +3h,
    2010-09-08-13:00:00--0500 +3h,
    2010-09-09-09:00:00--0500 +3h,
    2010-09-09-13:00:00--0500 +3h,
    2010-09-10-09:00:00--0500 +3h,
    2010-09-10-13:00:00--0500 +3h,
    2010-09-13-09:00:00--0500 +3h,
    2010-09-13-13:00:00--0500 +3h,
    2010-09-14-09:00:00--0500 +3h,
    2010-09-14-13:00:00--0500 +3h,
    2010-09-15-09:00:00--0500 +3h,
    2010-09-15-13:00:00--0500 +3h,
    2010-09-16-09:00:00--0500 +3h,
    2010-09-16-13:00:00--0500 +3h,
    2010-09-17-09:00:00--0500 +3h,
    2010-09-17-13:00:00--0500 +3h,
    2010-09-20-09:00:00--0500 +3h,
    2010-09-20-13:00:00--0500 +3h,
    2010-09-21-09:00:00--0500 +3h,
    2010-09-21-13:00:00--0500 +3h,
    2010-09-22-09:00:00--0500 +3h,
    2010-09-22-13:00:00--0500 +3h,
    2010-09-23-09:00:00--0500 +3h,
    2010-09-23-13:00:00--0500 +3h,
    2010-09-24-09:00:00--0500 +3h,
    2010-09-24-13:00:00--0500 +3h,
    2010-09-27-09:00:00--0500 +3h,
    2010-09-27-13:00:00--0500 +3h,
    2010-09-28-09:00:00--0500 +3h,
    2010-09-28-13:00:00--0500 +3h,
    2010-09-29-09:00:00--0500 +3h,
    2010-09-29-13:00:00--0500 +3h,
    2010-09-30-09:00:00--0500 +3h,
    2010-09-30-13:00:00--0500 +3h,
    2010-10-01-09:00:00--0500 +3h,
    2010-10-01-13:00:00--0500 +3h,
    2010-10-04-09:00:00--0500 +3h,
    2010-10-04-13:00:00--0500 +3h,
    2010-10-05-09:00:00--0500 +3h,
    2010-10-05-13:00:00--0500 +3h,
    2010-10-06-09:00:00--0500 +3h,
    2010-10-06-13:00:00--0500 +3h,
    2010-10-07-09:00:00--0500 +3h,
    2010-10-07-13:00:00--0500 +3h,
    2010-10-08-09:00:00--0500 +3h,
    2010-10-08-13:00:00--0500 +3h,
    2010-10-11-09:00:00--0500 +3h,
    2010-10-11-13:00:00--0500 +3h,
    2010-10-12-09:00:00--0500 +3h,
    2010-10-12-13:00:00--0500 +3h,
    2010-10-13-09:00:00--0500 +3h,
    2010-10-13-13:00:00--0500 +3h,
    2010-10-14-09:00:00--0500 +3h,
    2010-10-14-13:00:00--0500 +3h,
    2010-10-15-09:00:00--0500 +3h,
    2010-10-15-13:00:00--0500 +3h,
    2010-10-18-09:00:00--0500 +3h,
    2010-10-18-13:00:00--0500 +3h,
    2010-10-19-09:00:00--0500 +3h,
    2010-10-19-13:00:00--0500 +3h,
    2010-10-20-09:00:00--0500 +3h,
    2010-10-20-13:00:00--0500 +3h,
    2010-10-21-09:00:00--0500 +3h,
    2010-10-21-13:00:00--0500 +3h,
    2010-10-22-09:00:00--0500 +3h,
    2010-10-22-13:00:00--0500 +3h,
    2010-10-25-09:00:00--0500 +3h,
    2010-10-25-13:00:00--0500 +3h,
    2010-10-26-09:00:00--0500 +3h,
    2010-10-26-13:00:00--0500 +3h,
    2010-10-27-09:00:00--0500 +3h,
    2010-10-27-13:00:00--0500 +3h,
    2010-10-28-09:00:00--0500 +3h,
    2010-10-28-13:00:00--0500 +3h,
    2010-10-29-09:00:00--0500 +3h,
    2010-10-29-13:00:00--0500 +3h,
    2010-11-01-09:00:00--0500 +3h,
    2010-11-01-13:00:00--0500 +3h,
    2010-11-02-09:00:00--0500 +3h,
    2010-11-02-13:00:00--0500 +3h,
    2010-11-03-09:00:00--0500 +3h,
    2010-11-03-13:00:00--0500 +3h,
    2010-11-04-09:00:00--0500 +3h,
    2010-11-04-13:00:00--0500 +3h,
    2010-11-05-09:00:00--0500 +3h,
    2010-11-05-13:00:00--0500 +3h,
    2010-11-08-09:00:00--0600 +3h,
    2010-11-08-13:00:00--0600 +3h,
    2010-11-09-09:00:00--0600 +3h,
    2010-11-09-13:00:00--0600 +3h,
    2010-11-10-09:00:00--0600 +3h,
    2010-11-10-13:00:00--0600 +3h,
    2010-11-11-09:00:00--0600 +3h,
    2010-11-11-13:00:00--0600 +3h,
    2010-11-12-09:00:00--0600 +3h,
    2010-11-12-13:00:00--0600 +3h,
    2010-11-15-09:00:00--0600 +3h,
    2010-11-15-13:00:00--0600 +3h,
    2010-11-16-09:00:00--0600 +3h,
    2010-11-16-13:00:00--0600 +3h,
    2010-11-17-09:00:00--0600 +3h,
    2010-11-17-13:00:00--0600 +3h,
    2010-11-18-09:00:00--0600 +3h,
    2010-11-18-13:00:00--0600 +3h,
    2010-11-19-09:00:00--0600 +3h,
    2010-11-19-13:00:00--0600 +3h,
    2010-11-22-09:00:00--0600 +3h,
    2010-11-22-13:00:00--0600 +3h,
    2010-11-23-09:00:00--0600 +3h,
    2010-11-23-13:00:00--0600 +3h,
    2010-11-24-09:00:00--0600 +3h,
    2010-11-24-13:00:00--0600 +3h,
    2010-11-25-09:00:00--0600 +3h,
    2010-11-25-13:00:00--0600 +3h,
    2010-11-26-09:00:00--0600 +3h,
    2010-11-26-13:00:00--0600 +3h,
    2010-11-29-09:00:00--0600 +3h,
    2010-11-29-13:00:00--0600 +3h,
    2010-11-30-09:00:00--0600 +3h,
    2010-11-30-13:00:00--0600 +3h,
    2010-12-01-09:00:00--0600 +3h,
    2010-12-01-13:00:00--0600 +3h,
    2010-12-02-09:00:00--0600 +3h,
    2010-12-02-13:00:00--0600 +3h,
    2010-12-03-09:00:00--0600 +3h,
    2010-12-03-13:00:00--0600 +3h,
    2010-12-06-09:00:00--0600 +3h,
    2010-12-06-13:00:00--0600 +3h,
    2010-12-07-09:00:00--0600 +3h,
    2010-12-07-13:00:00--0600 +1h
}
supplement resource test {
  plan:booking accounting.software_testing.alpha
    2010-11-02-09:00:00--0500 +3h,
    2010-11-02-13:00:00--0500 +5h,
    2010-11-03-09:00:00--0500 +3h,
    2010-11-03-13:00:00--0500 +5h,
    2010-11-04-09:00:00--0500 +3h,
    2010-11-04-13:00:00--0500 +5h,
    2010-11-05-09:00:00--0500 +3h,
    2010-11-05-13:00:00--0500 +5h,
    2010-11-08-09:00:00--0600 +3h,
    2010-11-08-13:00:00--0600 +5h { overtime 2 }
  plan:booking accounting.software_testing.beta
    2010-11-09-09:00:00--0600 +3h,
    2010-11-09-13:00:00--0600 +5h,
    2010-11-10-09:00:00--0600 +3h,
    2010-11-10-13:00:00--0600 +5h,
    2010-11-11-09:00:00--0600 +3h,
    2010-11-11-13:00:00--0600 +5h,
    2010-11-12-09:00:00--0600 +3h,
    2010-11-12-13:00:00--0600 +5h,
    2010-11-15-09:00:00--0600 +3h,
    2010-11-15-13:00:00--0600 +5h,
    2010-11-16-09:00:00--0600 +3h,
    2010-11-16-13:00:00--0600 +5h,
    2010-11-17-09:00:00--0600 +3h,
    2010-11-17-13:00:00--0600 +5h,
    2010-11-18-09:00:00--0600 +3h,
    2010-11-18-13:00:00--0600 +5h,
    2010-11-19-09:00:00--0600 +3h,
    2010-11-19-13:00:00--0600 +5h,
    2010-11-22-09:00:00--0600 +3h,
    2010-11-22-13:00:00--0600 +5h
}

navigator navbar {
  hidereport 0
}

macro TaskTip [
  tooltip istask() -8<-
    '''Start: ''' <-query attribute='start'->
    '''End: ''' <-query attribute='end'->
    ----
    '''Resources:'''
    
    <-query attribute='resources'->
    ----
    '''Precursors: '''
    
    <-query attribute='precursors'->
    ----
    '''Followers: '''
    
    <-query attribute='followers'->
    ->8-
]

textreport frame "" {
  header -8<-
    == Accounting Software Project ==
    ----
    <[navigator id="navbar"]>
    ----
  ->8-
  footer "----"
  textreport index "Overview" {
    formats html
    center '<[report id="overview"]>'
  }

  textreport "Status" {
    formats html
    center -8<-
      <[report id="status.dashboard"]>
      ----
      <[report id="status.completed"]>
      ----
      <[report id="status.ongoing"]>
      ----
      <[report id="status.future"]>
    ->8-   
  }

  textreport development "Development" {
    formats html
    center '<[report id="development"]>'
  }

  textreport "Deliveries" {
    formats html
    center '<[report id="deliveries"]>'
  }

  textreport "ContactList" {
    formats html
    title "Contact List"
    center '<[report id="contactList"]>'
  }
  textreport "ResourceGraph" {
    formats html
    title "Resource Graph"
    center '<[report id="resourceGraph"]>'
  }
}

# A traditional Gantt chart with a project overview.
taskreport overview "" {
  header -8<-
    === Project Overview ===
    
    The project is structured into 3 phases.
    
    # Specification
    # <-reportlink id='frame.development'->
    # Testing
    
    === Original Project Plan ===
  ->8-
  columns hierarchindex,
          name, start, end, effort, duration, cost,
          revenue, chart { ${TaskTip} }
  # For this report we like to have the abbreviated weekday in front
  # of the date. %a is the tag for this.
  timeformat "%a %Y-%m-%d"
  loadunit days
  hideresource 1
  caption 'All effort values are in man days.'

  footer -8<-
    === Staffing ===
    
    All project phases are properly staffed. See [[ResourceGraph]] for
    detailed resource allocations.
    
    === Current Status ===
    
    The project started off with a delay of 4 days. This slightly affected
    the original schedule. See [[Deliveries]] for the impact on the
    delivery dates.
  ->8-
}

# Macro to set the background color of a cell according to the alert
# level of the task.
macro AlertColor [
  cellcolor plan.alert = 0 "#00D000" # green
  cellcolor plan.alert = 1 "#D0D000" # yellow
  cellcolor plan.alert = 2 "#D00000" # red
]

taskreport status "" {
  columns wbs, name, start, end, effort, alert { tooltip plan.journal
  != '' "<-query attribute='journal'->" }, status

  taskreport dashboard "" {
    headline "Project Dashboard (<-query attribute='now'->)"
    columns name { title "Task" ${AlertColor} },
            resources { width 200 ${AlertColor} 
                        start ${projectstart} end ${projectend} },
            alerttrend { title "Trend" ${AlertColor} },
            journalmessages { width 260 ${AlertColor} }
    hidetask ~hasalert(0)
    sorttasks alert.down
    period %{${now} - 1w} +1w
  }
  taskreport completed "" {
    headline "Already completed tasks"
  }
  taskreport ongoing "" {
    headline "Ongoing tasks"
  }
  taskreport future "" {
    headline "Future tasks"
  }
}

# A list of tasks showing the resources assigned to each task.
taskreport development "" {
  headline "Development - Resource Allocation Report"
  columns hierarchindex, name, start, end, effort { title "Work" },
          duration, chart { ${TaskTip} scale day width 500 }
  timeformat "%Y-%m-%d"
  hideresource ~(isleaf() & isleaf_())
  sortresources name.up
}

# A list of all tasks with the percentage completed for each task
taskreport deliveries "" {
  headline "Project Deliverables"
  columns hierarchindex, name, start, end, note { width 150 }, complete,
          chart { ${TaskTip} } 
  taskroot accounting.milestones
  hideresource 1
}
# A list of all employees with their contact details.
resourcereport contactList "" {
  headline "Contact list and duty plan"
  columns name,
          email { celltext 1 "[mailto:<-email-> <-email->]" },
          chart { scale day }
  hideresource ~isleaf()
  sortresources name.up
  hidetask 1
}

# A graph showing resource allocation. It identifies whether each
# resource is under- or over-allocated for.
resourcereport resourceGraph "" {
  headline "Resource Allocation Graph"
  columns no, name, effort, rate, weekly { ${TaskTip} }
  loadunit shortauto
  # We only like to show leaf tasks for leaf resources.
  hidetask ~(isleaf() & isleaf_())
  sorttasks plan.start.up
}